# Strategic Plan

Schedule from MS Project, 2005-08-01 to 2005-09-08, status date 2009-03-08, costs in $.
New Periodical Division
Coleman Publishing
This plan is to launch the new magazine and newsletter division.

## Calendars

- COLEMAN: Mon-Fri 08:00-12:00, 13:00-17:00; Sat-Sun off. Exceptions (off unless hours are given): 2005-09-05.

## Resources

| Resource | Group | Rate |
| --- | --- | --- |
| Business advisor | External | 30 |
| Peers |  | 25 |
| Lawyer |  | 150 |
| Government agency | External | 15 |
| Manager |  | 20 |
| Owners |  | 300 |
| Accountant |  | 18 |
| Banker | External | 25 |
| Information services |  | 100 |

## Schedule

| ID | WBS | Task | Type | Duration | Start | Finish | Predecessors | Baseline start | Baseline finish | Baseline duration | Total slack | Free slack | Constraint | Resources | Work | Cost | Baseline cost |
| --- | --- | --- | --- | --- | --- | --- | --- | --- | --- | --- | --- | --- | --- | --- | --- | --- | --- |
| 1 | 1 | **Self-Assessment** |  | 8d | 2005-08-01 | 2005-08-10 |  | 2005-08-01 | 2005-08-10 | 8d | 0d |  |  |  | 32h | 800 | 800 |
| 2 | 1.1 | Define business vision |  | 1d | 2005-08-01 | 2005-08-01 |  | 2005-08-01 | 2005-08-01 | 1d | 0d |  |  | Manager | 8h | 160 | 160 |
| 3 | 1.2 | Identify available skills, information and support |  | 2d | 2005-08-02 | 2005-08-09 | 2 | 2005-08-02 | 2005-08-09 | 2d | 0d |  |  | Business advisor | 16h | 480 | 480 |
| 4 | 1.3 | Decide whether to proceed |  | 1d | 2005-08-10 | 2005-08-10 | 3 | 2005-08-10 | 2005-08-10 | 1d | 0d |  | start no earlier than 2005-08-08 | Manager | 8h | 160 | 160 |
| 5 | 2 | **Define the Opportunity** |  | 10d | 2005-08-11 | 2005-08-24 |  | 2005-08-11 | 2005-08-24 | 10d | 0d |  |  |  | 96h | 13,408 | 13,408 |
| 6 | 2.1 | Research the market and competition |  | 1d | 2005-08-11 | 2005-08-11 | 4 | 2005-08-11 | 2005-08-11 | 1d | 0d |  | start no earlier than 2005-08-08 | Business advisor | 8h | 240 | 240 |
| 7 | 2.2 | Interview owners of similar businesses |  | 5d | 2005-08-12 | 2005-08-18 | 6 | 2005-08-12 | 2005-08-18 | 5d | 0d |  | start no earlier than 2005-08-08 | Owners | 40h | 12,000 | 12,000 |
| 8 | 2.3 | Identify needed resources |  | 2d | 2005-08-19 | 2005-08-22 | 7 | 2005-08-19 | 2005-08-22 | 2d | 0d |  |  | Business advisor; Peers | 32h | 880 | 880 |
| 9 | 2.4 | Identify operating cost elements |  | 2d | 2005-08-23 | 2005-08-24 | 8 | 2005-08-23 | 2005-08-24 | 2d | 0d |  |  | Accountant | 16h | 288 | 288 |
| 10 | 3 | **Evaluate Business Approach** |  | 4d | 2005-08-25 | 2005-08-30 |  | 2005-08-25 | 2005-08-30 | 4d | 0d |  |  |  | 32h | 640 | 640 |
| 11 | 3.1 | Define new entity requirements |  | 1d | 2005-08-25 | 2005-08-25 | 9 | 2005-08-25 | 2005-08-25 | 1d | 0d |  |  | Manager | 8h | 160 | 160 |
| 12 | 3.2 | Identify on-going business purchase opportunities |  | 1d | 2005-08-26 | 2005-08-26 | 11 | 2005-08-26 | 2005-08-26 | 1d | 0d |  |  | Manager | 8h | 160 | 160 |
| 13 | 3.3 | Research franchise possibilities |  | 1d | 2005-08-29 | 2005-08-29 | 12 | 2005-08-29 | 2005-08-29 | 1d | 0d |  |  | Manager | 8h | 160 | 160 |
| 14 | 3.4 | Summarize business approach |  | 1d | 2005-08-30 | 2005-08-30 | 13 | 2005-08-30 | 2005-08-30 | 1d | 0d |  |  | Manager | 8h | 160 | 160 |
| 15 | 4 | **Evaluate Potential Risks and Rewards** |  | 9d | 2005-08-26 | 2005-09-08 |  | 2005-08-26 | 2005-09-08 | 9d | 0d |  |  |  | 96h | 4,640 | 4,640 |
| 16 | 4.1 | Assess market size and stability |  | 2d | 2005-08-26 | 2005-08-29 | 11 | 2005-08-26 | 2005-08-29 | 2d | 3d | 0d |  | Business advisor | 16h | 480 | 480 |
| 17 | 4.2 | Estimate the competition |  | 1d | 2005-08-30 | 2005-08-30 | 16 | 2005-08-30 | 2005-08-30 | 1d | 3d | 0d |  | Business advisor | 8h | 240 | 240 |
| 18 | 4.3 | Assess needed resource availability |  | 2d | 2005-08-31 | 2005-09-01 | 17 | 2005-09-02 | 2005-09-06 | 2d | 3d | 0d |  | Business advisor | 16h | 480 | 480 |
| 19 | 4.4 | Evaluate realistic initial market share |  | 1d | 2005-09-02 | 2005-09-02 | 18 | 2005-09-07 | 2005-09-07 | 1d | 3d |  |  | Business advisor | 8h | 240 | 240 |
| 20 | 4.5 | Determine financial requirements |  | 2d | 2005-08-31 | 2005-09-01 | 14 | 2005-08-31 | 2005-09-01 | 2d | 0d |  |  | Business advisor | 16h | 480 | 480 |
| 21 | 4.6 | Review personal suitability |  | 1d | 2005-09-02 | 2005-09-02 | 20 | 2005-09-02 | 2005-09-02 | 1d | 0d |  |  | Manager | 8h | 160 | 160 |
| 22 | 4.7 | Evaluate initial profitability |  | 1d | 2005-09-06 | 2005-09-06 | 21 | 2005-09-06 | 2005-09-06 | 1d | 0d |  |  | Manager | 8h | 160 | 160 |
| 23 | 4.8 | Review and modify the strategic plan |  | 2d | 2005-09-07 | 2005-09-08 | 22 | 2005-09-07 | 2005-09-08 | 2d | 0d |  |  | Lawyer | 16h | 2,400 | 2,400 |
| 24 | 4.9 | Confirm decision to proceed | milestone | 0d | 2005-09-08 | 2005-09-08 | 23 | 2005-09-08 | 2005-09-08 | 0d | 0d |  |  | Manager |  |  |  |
