# StrategicPlan

Schedule from MS Project, 2009-03-09 to 2009-04-15.
UTI, AC, C2-13

## Calendars

- Standard: Mon-Fri 08:00-12:00, 13:00-17:00; Sat-Sun off.

## Resources

| Resource |
| --- |
| Manager |
| Business advisor |
| Owners |
| Peers |
| Accountant |
| Lawyer |

## Schedule

| ID | WBS | Task | Type | Duration | Start | Finish | Predecessors | Baseline start | Baseline finish | Baseline duration | Total slack | Free slack | Constraint | Resources | Work | Baseline cost |
| --- | --- | --- | --- | --- | --- | --- | --- | --- | --- | --- | --- | --- | --- | --- | --- | --- |
| 1 | 1 | **Strategic Plan** |  | 28d | 2009-03-09 | 2009-04-15 |  | 2005-08-01 | 2005-09-08 | 28d | 0d |  |  |  | 256h | 19,488 |
| 2 | 1 | **Self-Assessment** |  | 8d | 2009-03-09 | 2009-03-18 |  | 2005-08-01 | 2005-08-10 | 8d | 0d |  |  |  | 32h | 800 |
| 3 | 1.1 | Define business vision |  | 1d | 2009-03-09 | 2009-03-09 |  | 2005-08-01 | 2005-08-01 | 1d | 0d |  |  | Manager | 8h | 160 |
| 4 | 1.2 | Identify available skills, information and support |  | 2d | 2009-03-10 | 2009-03-17 | 3 | 2005-08-02 | 2005-08-09 | 2d | 0d |  |  | Business advisor | 16h | 480 |
| 5 | 1.3 | Decide whether to proceed |  | 1d | 2009-03-18 | 2009-03-18 | 4 | 2005-08-10 | 2005-08-10 | 1d | 0d |  | start no earlier than 2005-08-08 | Manager | 8h | 160 |
| 6 | 2 | **Define the Opportunity** |  | 10d | 2009-03-19 | 2009-04-01 |  | 2005-08-11 | 2005-08-24 | 10d | 0d |  |  |  | 96h | 13,408 |
| 7 | 2.1 | Research the market and competition |  | 1d | 2009-03-19 | 2009-03-19 | 5 | 2005-08-11 | 2005-08-11 | 1d | 0d |  | start no earlier than 2005-08-08 | Business advisor | 8h | 240 |
| 8 | 2.2 | Interview owners of similar businesses |  | 5d | 2009-03-20 | 2009-03-26 | 7 | 2005-08-12 | 2005-08-18 | 5d | 0d |  | start no earlier than 2005-08-08 | Owners | 40h | 12,000 |
| 9 | 2.3 | Identify needed resources |  | 2d | 2009-03-27 | 2009-03-30 | 8 | 2005-08-19 | 2005-08-22 | 2d | 0d |  |  | Business advisor; Peers | 32h | 880 |
| 10 | 2.4 | Identify operating cost elements |  | 2d | 2009-03-31 | 2009-04-01 | 9 | 2005-08-23 | 2005-08-24 | 2d | 0d |  |  | Accountant | 16h | 288 |
| 11 | 3 | **Evaluate Business Approach** |  | 4d | 2009-04-02 | 2009-04-07 |  | 2005-08-25 | 2005-08-30 | 4d | 0d |  |  |  | 32h | 640 |
| 12 | 3.1 | Define new entity requirements |  | 1d | 2009-04-02 | 2009-04-02 | 10 | 2005-08-25 | 2005-08-25 | 1d | 0d |  |  | Manager | 8h | 160 |
| 13 | 3.2 | Identify on-going business purchase opportunities |  | 1d | 2009-04-03 | 2009-04-03 | 12 | 2005-08-26 | 2005-08-26 | 1d | 0d |  |  | Manager | 8h | 160 |
| 14 | 3.3 | Research franchise possibilities |  | 1d | 2009-04-06 | 2009-04-06 | 13 | 2005-08-29 | 2005-08-29 | 1d | 0d |  |  | Manager | 8h | 160 |
| 15 | 3.4 | Summarize business approach |  | 1d | 2009-04-07 | 2009-04-07 | 14 | 2005-08-30 | 2005-08-30 | 1d | 0d |  |  | Manager | 8h | 160 |
| 16 | 4 | **Evaluate Potential Risks and Rewards** |  | 9d | 2009-04-03 | 2009-04-15 |  | 2005-08-26 | 2005-09-08 | 9d | 0d |  |  |  | 96h | 4,640 |
| 17 | 4.1 | Assess market size and stability |  | 2d | 2009-04-03 | 2009-04-06 | 12 | 2005-08-26 | 2005-08-29 | 2d | 3d | 0d |  | Business advisor | 16h | 480 |
| 18 | 4.2 | Estimate the competition |  | 1d | 2009-04-07 | 2009-04-07 | 17 | 2005-08-30 | 2005-08-30 | 1d | 3d | 0d |  | Business advisor | 8h | 240 |
| 19 | 4.3 | Assess needed resource availability |  | 2d | 2009-04-08 | 2009-04-09 | 18 | 2005-09-02 | 2005-09-06 | 2d | 3d | 0d |  | Business advisor | 16h | 480 |
| 20 | 4.4 | Evaluate realistic initial market share |  | 1d | 2009-04-10 | 2009-04-10 | 19 | 2005-09-07 | 2005-09-07 | 1d | 3d |  |  | Business advisor | 8h | 240 |
| 21 | 4.5 | Determine financial requirements |  | 2d | 2009-04-08 | 2009-04-09 | 15 | 2005-08-31 | 2005-09-01 | 2d | 0d |  |  | Business advisor | 16h | 480 |
| 22 | 4.6 | Review personal suitability |  | 1d | 2009-04-10 | 2009-04-10 | 21 | 2005-09-02 | 2005-09-02 | 1d | 0d |  |  | Manager | 8h | 160 |
| 23 | 4.7 | Evaluate initial profitability |  | 1d | 2009-04-13 | 2009-04-13 | 22 | 2005-09-06 | 2005-09-06 | 1d | 0d |  |  | Manager | 8h | 160 |
| 24 | 4.8 | Review and modify the strategic plan |  | 2d | 2009-04-14 | 2009-04-15 | 23 | 2005-09-07 | 2005-09-08 | 2d | 0d |  |  | Lawyer | 16h | 2,400 |
| 25 | 4.9 | Confirm decision to proceed | milestone | 0d | 2009-04-15 | 2009-04-15 | 24 | 2005-09-08 | 2005-09-08 | 0d | 0d |  |  | Manager |  |  |

Notes:
- 1: This plan is to launch the new magazine and newsletter division.
